# План выполнения работ, ред. 01(2003)

Schedule from MS Project, 2011-03-14 to 2011-06-02, costs in р..
***

## Calendars

- Стандартный: Mon-Fri 09:00-13:00, 14:00-18:00; Sat-Sun off.

## Resources

| Resource | Rate |
| --- | --- |
| Руководитель проекта | 400 |
| Разработчик системы 1 | 350 |
| Разработчик системы 2 | 350 |
| Архитектор системы | 350 |
| Постановщик задач исполнителя 1 | 300 |
| Технический специалист | 300 |
| Специалист по внедрению | 300 |
| Разработчик документации | 250 |

## Schedule

| ID | WBS | Task | Duration | Start | Finish | Predecessors | Total slack | Free slack | Constraint | Resources | Work | Cost |
| --- | --- | --- | --- | --- | --- | --- | --- | --- | --- | --- | --- | --- |
| 1 | 1 | **Создание информационной системы «БАЛТИК-ЛАЙТ»** | 59d | 2011-03-14 | 2011-06-02 |  | 0d |  |  |  | 1252h | 428,200 |
| 2 | 1.1 | **Этап 1. Прием заявок и обеспечение производства** | 47d | 2011-03-14 | 2011-05-17 |  | 0d |  |  |  | 544h | 184,800 |
| 3 | 1.1.1 | Настройка информационных объектов учета и анализа для разрабатываемых подсистем Прием заявок и обеспечение производства | 5d | 2011-03-14 | 2011-03-18 |  | 54d |  |  | Архитектор системы | 40h | 14,000 |
| 4 | 1.1.2 | Установка и настройка БД БАЛТИК-ЛАЙТ | 1d | 2011-03-14 | 2011-03-14 |  | 0d |  |  | Технический специалист | 8h | 2,400 |
| 5 | 1.1.3 | Миграция данных из существующих систем (1С, Excel) | 8d | 2011-03-15 | 2011-03-24 | 4 | 50d |  | start no earlier than 2010-05-10 | Технический специалист | 64h | 19,200 |
| 6 | 1.1.4 | Настройка оргштатной структуры компании | 1d | 2011-03-15 | 2011-03-15 | 4 | 57d |  |  | Архитектор системы | 8h | 2,800 |
| 7 | 1.1.5 | Классификация сырья и материалов | 3d | 2011-03-15 | 2011-03-17 | 4 | 0d |  |  | Архитектор системы | 24h | 8,400 |
| 8 | 1.1.6 | Типизация продукции | 4d | 2011-03-18 | 2011-03-23 | 7 | 0d |  |  | Разработчик системы 1 | 32h | 11,200 |
| 9 | 1.1.7 | Разработка требуемой функциональности и уровней доступа к системе | 20d | 2011-03-15 | 2011-04-11 | 4 | 12d | 0d |  | Разработчик системы 1 | 160h | 56,000 |
| 10 | 1.1.8 | Формирование необходимых печатных форм в рамках процессов Прием заявок и обеспечение производства | 21d | 2011-04-12 | 2011-05-10 | 9 | 12d | 0d |  | Разработчик системы 2 | 168h | 58,800 |
| 11 | 1.1.9 | Отладка разработанных подсистем и исправление ошибок | 4d | 2011-05-11 | 2011-05-16 | 10 | 12d | 0d |  | Специалист по внедрению | 32h | 9,600 |
| 12 | 1.1.10 | Обучение и тестовая эксплуатация | 1d | 2011-05-17 | 2011-05-17 | 11 | 12d |  |  | Специалист по внедрению | 8h | 2,400 |
| 13 | 1.2 | **Этап 2. Производство, транспортировка, монтаж** | 32.5d | 2011-03-24 | 2011-05-09 |  | 0d |  |  |  | 372h | 128,600 |
| 14 | 1.2.1 | Настройка информационных объектов учета и анализа для разрабатываемых подсистем Производство, транспортировка, монтаж | 10d | 2011-03-24 | 2011-04-06 | 8 | 0d |  | start no earlier than 2010-05-10 | Архитектор системы | 80h | 28,000 |
| 15 | 1.2.2 | Разработка требуемой функциональности для подсистемы Производство, транспортировка, монтаж | 22.5d | 2011-04-07 | 2011-05-09 | 14 | 18.5d |  |  | Разработчик системы 1 | 180h | 63,000 |
| 16 | 1.2.3 | Формирование необходимых печатных форм в рамках процессов Производство, транспортировка, монтаж | 10d | 2011-04-07 | 2011-04-20 | 14 | 0d |  |  | Разработчик системы 2 | 80h | 28,000 |
| 17 | 1.2.4 | Отладка разработанных подсистем и исправление ошибок | 3d | 2011-04-21 | 2011-04-25 | 16 | 0d |  |  | Специалист по внедрению | 24h | 7,200 |
| 18 | 1.2.5 | Обучение и тестовая эксплуатация | 1d | 2011-04-26 | 2011-04-26 | 17 | 0d |  |  | Специалист по внедрению | 8h | 2,400 |
| 19 | 1.3 | **Этап 3. Финансы и кадры** | 24d | 2011-04-27 | 2011-05-30 |  | 0d |  |  |  | 312h | 107,600 |
| 20 | 1.3.1 | Настройка информационных объектов учета и анализа для разрабатываемых подсистем Финансы и кадры | 8d | 2011-04-27 | 2011-05-06 | 18 | 0d |  | start no earlier than 2010-05-10 | Архитектор системы | 64h | 22,400 |
| 21 | 1.3.2 | Разработка требуемой функциональности для подсистемы Финансы и кадры | 15d | 2011-05-09 | 2011-05-27 | 20 | 4d |  |  | Разработчик системы 1 | 120h | 42,000 |
| 22 | 1.3.3 | Формирование необходимых печатных форм в рамках процессов Финансы и кадры | 12d | 2011-05-09 | 2011-05-24 | 20 | 0d |  |  | Разработчик системы 2 | 96h | 33,600 |
| 23 | 1.3.4 | Отладка разработанных подсистем и исправление ошибок | 2d | 2011-05-25 | 2011-05-26 | 22 | 0d |  |  | Специалист по внедрению | 16h | 4,800 |
| 24 | 1.3.5 | Обучение и тестовая эксплуатация | 2d | 2011-05-27 | 2011-05-30 | 23 | 0d |  |  | Специалист по внедрению | 16h | 4,800 |
| 25 | 1.4 | Тестовая эксплуатация системы в целом и запуск в промышленную эксплуатацию | 3d | 2011-05-31 | 2011-06-02 | 24 | 0d |  |  | Специалист по внедрению | 24h | 7,200 |
